# 3GPP_Release-2000

Schedule from MS Project, 2000-01-03 to 2009-03-30, A marks actual dates.

## Calendars

- Standard: Mon-Fri 08:00-12:00, 13:00-17:00; Sat-Sun off.

## Resources

| Resource |
| --- |
| NP |
| N1 |
| N2 |
| N3 |
| N4 |
| N5 |
| TP |
| T1 |
| T2 |
| T3 |
| RP |
| R1 |
| R2 |
| R3 |
| R4 |
| SP |
| S1 |
| S2 |
| S3 |
| S4 |
| S5 |
| PCG |
| GP |
| No |
| CN4 |
| ? |
| WG G2 |
| G2 |
| G1 |
| G4 |
| G3 |
| All |
| Generic |
| MLST |
| G5 |
| S3; G2 |
| WG T2 |
| GP;G1 |
| G4;G5 |
| OMA |
| GP-G2 |
| Yes |
| GP; |
| N4; |
| GP; N1 |
| CT5 |
| C5 |
| C1 |
| C4 |
| C3 |
| C6 |
| G1; |
| 4 |
| ct |
| c;s;r |
| CT;RAN;SA |
| G2, |
| G1; G3 |
| CT6 |
| CT1 |
| CT1, CT3, CT4 |
| C1, C3, C4 |
| CP |
| R5 |

## Schedule

| ID | WBS | Task | Duration | Start | Finish | Complete | Remaining | Baseline start | Baseline finish | Baseline duration | Total slack | Constraint | Resources | Work | Actual work | Text9 | Text6 | Text1 | Text4 | Text8 | Text3 | Text5 |
| --- | --- | --- | --- | --- | --- | --- | --- | --- | --- | --- | --- | --- | --- | --- | --- | --- | --- | --- | --- | --- | --- | --- |
| 1 | 1 | VERSION 2007 June 22nd | 1d | 2000-01-03 | 2000-01-03 |  |  | 2000-01-03 | 2000-01-03 | 1d | 2410d |  |  |  |  | 2044 |  |  |  |  |  |  |
| 2 | 2 | "CTRL + a" to display all the 3GPP fields | 1d | 2000-01-03 | 2000-01-03 |  |  | 2000-01-03 | 2000-01-03 | 1d | 2335d |  |  |  |  | 1462 |  |  |  |  |  |  |
| 3 | 3 | Content of Rel-8 (not frozen) | 1d | 2000-01-03 | 2000-01-03 |  |  | 2000-01-03 | 2000-01-03 | 1d | 2335d |  |  |  |  | 2058 |  |  |  |  |  |  |
| 5 | 4 | Release 8 Features | 1d? | 2000-01-03 | 2000-01-03 |  |  | 2000-01-03 | 2000-01-03 | 1d? | 2335d |  | CT;RAN;SA | 8h |  |  | Rel-8 |  |  |  |  |  |
| 6 | 5 | **3G Long Term Evolution** | 376d? | 2006-09-25 A | 2008-03-03 | 27% | 275.39d? | 2006-09-25 | 2007-12-14 | 320d? | 280d |  | RP | 14984h | 3531.6h |  | Rel-8 | LTE | Takehiro Nakamura (NTT DoCoMo) | MCC_RAN |  |  |
| 7 | 5.1 | LTE – Physical Layer | 255d? | 2006-09-25 A | 2007-09-14 | 65% | 89.25d? | 2006-09-25 | 2007-09-14 | 255d? | 401d | finish no earlier than 2007-09-14 | R1 | 2040h | 1326h |  | Rel-8 | LTE-Phys | Sadayuki Abeta, NTT DoCoMo | MCC_RAN | 36.2xy |  |
| 8 | 5.2 | LTE – Radio Interface Layer 2 and 3 Protocol Aspect | 255d? | 2006-09-25 A | 2007-09-14 | 20% | 204d? | 2006-09-25 | 2007-09-14 | 255d? | 401d | finish no earlier than 2007-09-14 | R2 | 2040h | 408h |  | Rel-8 | LTE-L23 | Benoist Sebire, Nokia | MCC_RAN | 36.3xy |  |
| 9 | 5.3 | LTE – eUTRAN Interfaces | 255d? | 2006-09-25 A | 2007-09-14 | 20% | 204d? | 2006-09-25 | 2007-09-14 | 255d? | 401d | finish no earlier than 2007-09-14 | R3 | 2040h | 408h |  | Rel-8 | LTE-interfaces | Mattias Wahlqvist, Ericsson | MCC_RAN | 36.4xy |  |
| 10 | 5.4 | LTE – RF Radio Transmission/Reception, System Performance Requirements and Conformance Testing | 320d? | 2006-09-25 A | 2007-12-14 | 40% | 192d? | 2006-09-25 | 2007-12-14 | 320d? | 336d | finish no earlier than 2007-12-14 | R4 | 2560h | 1024h |  | Rel-8 | LTE-RF | Frank Lamprecht, Siemens | MCC_RAN | 36.1xy |  |
| 11 | 5.5 | **LTE – Terminal Conformance Test Specifications** | 197d? | 2007-06-01 | 2008-03-03 |  |  | 2006-03-15 | 2007-03-15 | 262d? | 280d |  | R5 | 3296h |  |  | Rel-8 | LTE-UEConTest | Catherine Salinoc, NEC | MCC_RAN |  | catherine.salinoc@nectech.fr |
| 12 | 5.5.1 | 3G Long Term Evolution – Terminal Protocol Conformance Test Specifications | 197d? | 2007-06-01 | 2008-03-03 |  |  | 2006-03-15 | 2007-03-15 | 262d? | 280d | start no earlier than 2007-06-01 | R5 | 1576h |  |  | Rel-8 | LTE-UEConTest_SIG | Catherine Salinoc (NEC), Jacob John (Motorola) | Stoyan Baev | TS 36.508, 36.523-1, 36.523-2, 36.523-3 | catherine.salinoc@nectech.fr, Jacob.John@motorola.com |
| 13 | 5.5.2 | 3G Long Term Evolution – Terminal Radio Transmission and Reception Conformance Test Specifications | 197d? | 2007-06-01 | 2008-03-03 |  |  | 2006-03-15 | 2007-03-15 | 262d? | 280d | start no earlier than 2007-06-01 | R5 | 1576h |  |  | Rel-8 | LTE-UEConTest_RF | Catherine Salinoc, NEC | Stoyan Baev | TS 36.508, 36.521-1, 36.521-2 | catherine.salinoc@nectech.fr |
| 14 | 6 | **3GPP System Architecture Evolution Specification** | 462d? | 2006-06-08 A | 2008-03-14 | 11% | 409.63d? | 2006-06-08 | 2007-09-14 | 332d? | 271d |  | S2 | 91112h | 9993.79h |  | Rel-8 | SAES | Osok Song (Samsung) | Maurice | 23.228, 23.279 | osok.song@samsung.com |
| 15 | 6.1 | Requirements for evolution of the 3GPP system architecture | 157d? | 2006-06-08 A | 2007-01-12 | 95% | 7.85d? | 2006-06-08 | 2007-01-12 | 157d? | 576d | finish no earlier than 2007-01-12 | S1 | 1256h | 1193.2h |  | Rel-8 | AIPN-SAE | Michael Kurz (T-Mobile International) | Michael | 22.278 | michael.kurz@t-mobile.at |
| 16 | 6.2 | **SA aspects of System Architecture Evolution** | 240d? | 2007-01-02 A | 2007-12-03 | 32% | 164.24d? |  |  |  | 345d |  | S2 | 21352h | 6044h |  | Rel-8 | SAES-SA |  |  |  |  |
| 17 | 6.2.1 | High level functions (common high level functions for all accesses) | 179d? | 2007-01-02 A | 2007-09-07 | 60% | 71.6d? |  |  |  | 406d | finish no earlier than 2007-09-07 | S2 | 1432h | 859.2h |  | Rel-8 | SAES-SA-HLF |  |  |  |  |
| 18 | 6.2.2 | **Functions and procedures for SAE to support LTE access** | 240d? | 2007-01-02 A | 2007-12-03 | 38% | 147.72d? |  |  |  | 345d |  | S2 | 5272h | 1933.2h |  | Rel-8 | SAES-SA-FP_LTE |  |  |  |  |
| 19 | 7.2.2.1 | SAES-SA-FP_LTE with GTP variant | 179d? | 2007-01-02 A | 2007-09-07 | 45% | 98.45d? |  |  |  | 406d | start no earlier than 2007-01-02 | S2 | 1432h | 644.4h |  | Rel-8 | SAES-SA-FP_LTE-GTP |  |  |  |  |
| 20 | 7.2.2.2 | SAES-SA-FP_LTE with IETF variant | 240d? | 2007-01-02 A | 2007-12-03 | 34% | 159.45d? |  |  |  | 345d | finish no earlier than 2007-12-01 | S2 | 1920h | 644.4h |  | Rel-8 | SAES-SA-FP_LTE-IETF |  |  |  |  |
| 21 | 6.2.3 | Functions and procedures for SAE to support 3GPP accesses (LTE <-> 2G/3G) | 179d? | 2007-01-02 A | 2007-09-07 | 45% | 98.45d? |  |  |  | 406d | finish no earlier than 2007-09-07 | S2 | 1432h | 644.4h |  | Rel-8 | SAES-SA-FP_3GPP |  |  |  |  |
| 22 | 6.2.4 | **Functions and procedures for SAE to support non-3GPP accesses** | 240d? | 2007-01-02 A | 2007-12-03 | 35% | 156d? |  |  |  | 345d |  | S2 | 5272h | 1651.2h |  | Rel-8 | SAES-SA-FP_n3GPP |  |  |  |  |
| 23 | 7.2.4.1 | SAES-SA-FP_n3GPP Host-based Mobility aspects | 179d? | 2007-01-02 A | 2007-09-07 | 35% | 116.35d? |  |  |  | 406d | finish no earlier than 2007-09-07 | S2 | 1432h | 501.2h |  | Rel-8 | SAES-SA-FP_n3GPP-HBMob |  |  |  |  |
| 24 | 7.2.4.2 | SAES-SA-FP_n3GPP Network-based Mobility aspects | 240d? | 2007-01-02 A | 2007-12-03 | 35% | 156d? |  |  |  | 345d | finish no earlier than 2007-12-01 | S2 | 1920h | 672h |  | Rel-8 | SAES-SA-FP_n3GPP-NBMob |  |  |  |  |
| 25 | 6.2.5 | Functions and procedures for SAE to support LTE MBMS | 115d? | 2007-06-25 | 2007-11-30 |  |  |  |  |  | 346d | start no earlier than 2007-06-25 | S2 | 920h |  |  | Rel-8 | SAES-SA-FP_LTEMBMS |  |  |  |  |
| 26 | 6.2.6 | Functions and procedures for SAE to support LCS | 80d? | 2007-08-13 | 2007-11-30 |  |  |  |  |  | 346d | start no earlier than 2007-08-13 | S2 | 640h |  |  | Rel-8 | SAES-SA-FP_LCS |  |  |  |  |
| 27 | 6.2.7 | Single Radio Voice Call Continuity | 239d? | 2007-01-02 A | 2007-12-01 | 20% | 191.2d? |  |  |  | 346d | finish no earlier than 2007-12-01 | S2 | 1912h | 382.4h |  | Rel-8 | SAES-SA-SR_VCC |  |  |  |  |
| 28 | 6.2.8 | SAE impacts on IMS | 239d? | 2007-01-02 A | 2007-12-01 | 30% | 167.3d? |  |  |  | 346d | finish no earlier than 2007-12-01 | S2 | 1912h | 573.6h |  | Rel-8 | SAES-SA-on_IMS |  |  |  |  |
| 29 | 6.2.9 | SAE aspects of Emergency Calls | 80d? | 2007-08-13 | 2007-11-30 |  |  |  |  |  | 346d | start no earlier than 2007-08-13 | S2 | 640h |  |  | Rel-8 | SAES-SA-EmCall |  |  |  |  |

Notes:
- 11: BB place holder for a number of RAN5 Tasks
- 12: Dependent on RAN as well as on CT/SA WIs
- 14: S2#52: Specification phase created. New WID approved SA#32
- 15: Moved to SA2 at SA#32
- 16: S2 internal target is September 2007
- 26: SA2 need RAN outputs (RAN dependencies)

| ID | WBS | Task | Duration | Start | Finish | Complete | Remaining | Baseline start | Baseline finish | Baseline duration | Total slack | Constraint | Resources | Work | Actual work | Text1 | Text4 | Text5 | Text6 | Text8 | Text12 |
| --- | --- | --- | --- | --- | --- | --- | --- | --- | --- | --- | --- | --- | --- | --- | --- | --- | --- | --- | --- | --- | --- |
| 30 | 6.3 | **CT aspects of System Architecture Evolution** | 290d? | 2007-02-05 A | 2008-03-14 | 3% | 281.13d? | 2007-02-05 | 2008-03-14 | 290d? | 271d |  | CP | 59320h | 1780.06h | SAES-St3 | Hannu Hietalahti, Nokia | hannu.hietalahti@nokia.com | Rel-8 | Andrijana, Seung Don, Kimmo |  |
| 31 | 6.3.1 | **CT1 aspects of SAES** | 290d? | 2007-02-05 A | 2008-03-14 | 3% | 282.27d? | 2007-02-05 | 2008-03-14 | 290d? | 271d |  | C1 | 16240h | 433.07h | SAES-St3 |  |  | Rel-8 |  |  |
| 32 | 6.3.1.1 | Network selection procedures | 290d? | 2007-02-05 | 2008-03-14 |  |  | 2007-02-05 | 2008-03-14 | 290d? | 271d | start no earlier than 2007-02-05 | C1 | 2320h |  | SAES-St3-netsel |  |  | Rel-8 |  |  |
| 33 | 6.3.1.2 | UE NAS mobility procedures in idle and active mode | 290d? | 2007-02-05 A | 2008-03-14 | 4% | 278.4d? | 2007-02-05 | 2008-03-14 | 290d? | 271d | start no earlier than 2007-02-05 | C1 | 2320h | 92.8h | SAES-St3-NASmob |  |  | Rel-8 |  |  |
| 34 | 6.3.1.3 | Bearer control and QoS aspects | 290d? | 2007-02-05 A | 2008-03-14 | 4% | 278.4d? | 2007-02-05 | 2008-03-14 | 290d? | 271d | start no earlier than 2007-02-05 | C1 | 2320h | 92.8h | SAES-St3-BCQOS |  |  | Rel-8 |  |  |
| 35 | 6.3.1.4 | CT1 SAE impact on existing capabilities | 290d? | 2007-02-05 | 2008-03-14 |  |  | 2007-02-05 | 2008-03-14 | 290d? | 271d | start no earlier than 2007-02-05 | C1 | 2320h |  | SAES-St3-CT1imp |  |  | Rel-8 |  |  |
| 36 | 6.3.1.5 | Interoperability | 290d? | 2007-02-05 A | 2008-03-14 | 4% | 278.4d? | 2007-02-05 | 2008-03-14 | 290d? | 271d | start no earlier than 2007-02-05 | C1 | 2320h | 92.8h | SAES-St3-interop |  |  | Rel-8 |  |  |
| 37 | 6.3.1.6 | CT1 security aspects | 290d? | 2007-02-05 A | 2008-03-14 | 4% | 278.4d? | 2007-02-05 | 2008-03-14 | 290d? | 271d | start no earlier than 2007-02-05 | C1 | 2320h | 92.8h | SAES-St3-CT1sec |  |  | Rel-8 |  |  |
| 38 | 6.3.2 | **CT3 aspects of SAES** | 290d? | 2007-02-05 | 2008-03-14 |  |  | 2007-02-05 | 2008-03-14 | 290d? | 271d |  | C3 | 11600h |  | SAES-St3 |  |  | Rel-8 |  |  |
| 39 | 6.3.2.1 | PCC aspects of SAE | 290d? | 2007-02-05 | 2008-03-14 |  |  | 2007-02-05 | 2008-03-14 | 290d? | 271d | start no earlier than 2007-02-05 | C3 | 2320h |  | SAES-St3-PCC |  |  | Rel-8 |  |  |
| 40 | 6.3.2.2 | Interworking between EPC and external PDNs | 290d? | 2007-02-05 | 2008-03-14 |  |  | 2007-02-05 | 2008-03-14 | 290d? | 271d | start no earlier than 2007-02-05 | C3 | 2320h |  | SAES-St3-intwk |  |  | Rel-8 |  |  |
| 41 | 6.3.2.3 | QoS mechanisms | 290d? | 2007-02-05 | 2008-03-14 |  |  | 2007-02-05 | 2008-03-14 | 290d? | 271d | start no earlier than 2007-02-05 | C3 | 2320h |  | SAES-St3-QoS |  |  | Rel-8 |  |  |
| 42 | 6.3.2.4 | CT3 SAE impact on existing capabilities | 290d? | 2007-02-05 | 2008-03-14 |  |  | 2007-02-05 | 2008-03-14 | 290d? | 271d | start no earlier than 2007-02-05 | C3 | 2320h |  | SAES-St3-CT3imp |  |  | Rel-8 |  |  |
| 43 | 6.3.3 | **CT4 aspects of SAES** | 290d? | 2007-02-05 A | 2008-03-14 | 5% | 275.5d? | 2007-02-05 | 2007-09-21 | 165d? | 271d |  | C4 | 25520h | 1276h | SAES-St3 |  |  | Rel-8 |  |  |
| 44 | 6.3.3.1 | EPC - HSS interface | 290d? | 2007-02-05 A | 2008-03-14 | 5% | 275.5d? | 2007-02-05 | 2007-09-21 | 165d? | 271d | finish no earlier than 2008-03-14 | C4 | 2320h | 116h | SAES-St3-EPC_HSS |  |  | Rel-8 |  |  |
| 45 | 6.3.3.2 | Within EPC | 290d? | 2007-02-05 A | 2008-03-14 | 5% | 275.5d? | 2007-02-05 | 2007-09-21 | 165d? | 271d | finish no earlier than 2008-03-14 | C4 | 2320h | 116h | SAES-St3-EPC |  |  | Rel-8 |  |  |
| 46 | 6.3.3.3 | EPC - GPRS | 290d? | 2007-02-05 A | 2008-03-14 | 5% | 275.5d? | 2007-02-05 | 2007-09-21 | 165d? | 271d | finish no earlier than 2008-03-14 | C4 | 2320h | 116h | SAES-St3-EPC_GPRS |  |  | Rel-8 |  |  |
| 47 | 6.3.3.4 | EPC - non-3GPP IP access | 290d? | 2007-02-05 A | 2008-03-14 | 5% | 275.5d? | 2007-02-05 | 2007-09-21 | 165d? | 271d | finish no earlier than 2008-03-14 | C4 | 2320h | 116h | SAES-St3-EPC_n3G |  |  | Rel-8 |  |  |
| 48 | 6.3.3.5 | AAA/HSS related | 290d? | 2007-02-05 A | 2008-03-14 | 5% | 275.5d? | 2007-02-05 | 2007-09-21 | 165d? | 271d | finish no earlier than 2008-03-14 | C4 | 2320h | 116h | SAES-St3-AAA_HSS |  |  | Rel-8 |  |  |
| 49 | 6.3.3.6 | EPC - AAA interface | 290d? | 2007-02-05 A | 2008-03-14 | 5% | 275.5d? | 2007-02-05 | 2007-09-21 | 165d? | 271d | finish no earlier than 2008-03-14 | C4 | 2320h | 116h | SAES-St3-EPC_AAA |  |  | Rel-8 |  |  |
| 50 | 6.3.3.7 | EPC - EPC | 290d? | 2007-02-05 A | 2008-03-14 | 5% | 275.5d? | 2007-02-05 | 2007-09-21 | 165d? | 271d | finish no earlier than 2008-03-14 | C4 | 2320h | 116h | SAES-St3-EPC_EPC |  |  | Rel-8 |  |  |
| 51 | 6.3.3.8 | SAE / LTE identities | 290d? | 2007-02-05 A | 2008-03-14 | 5% | 275.5d? | 2007-02-05 | 2007-09-21 | 165d? | 271d | finish no earlier than 2008-03-14 | C4 | 2320h | 116h | SAES-St3-IDs |  |  | Rel-8 |  |  |
| 52 | 6.3.3.9 | MME - SGSN "signalling free" protocol | 290d? | 2007-02-05 A | 2008-03-14 | 5% | 275.5d? | 2007-02-05 | 2007-09-21 | 165d? | 271d | finish no earlier than 2008-03-14 | C4 | 2320h | 116h | SAES-St3-MME_SGSN |  |  | Rel-8 |  |  |
| 53 | 6.3.3.10 | CT4 SAE impact on existing capabilities | 290d? | 2007-02-05 A | 2008-03-14 | 5% | 275.5d? | 2007-02-05 | 2007-09-21 | 165d? | 271d | finish no earlier than 2008-03-14 | C4 | 2320h | 116h | SAES-St3-impacts |  |  | Rel-8 |  |  |
| 54 | 6.3.4 | Deleted - UE to EPC NAS signalling (incl. MBMS and QoS aspects) | 290d? | 2007-02-05 | 2008-03-14 |  |  | 2007-02-05 | 2008-03-14 | 290d? | 271d | start no earlier than 2007-02-05 | C1 | 2320h |  | SAES-St3-sig |  |  | Rel-8 |  |  |
| 55 | 6.3.5 | Deleted -User and Control plane protocols | 165d? | 2007-02-05 | 2007-09-21 |  |  | 2007-02-05 | 2007-09-21 | 165d? | 396d | finish no earlier than 2007-09-21 | C4 | 1320h |  | SAES-St3-prot |  |  | Rel-8 |  |  |
| 56 | 6.4 | Deleted - GPRS enhancements for LTE access | 198d? | 2006-12-01 A | 2007-09-04 | 15% | 168.3d? | 2006-12-01 | 2007-09-04 | 198d? | 409d | start no earlier than 2006-12-01 | S2 | 1584h | 237.6h | SAES-GPRS_LTE | Chris Pudney (Vodafone) | chris.pudney@vodafone.com | Rel-8 | Maurice |  |
| 57 | 6.5 | Deleted - Architecture enhancements for non-3GPP accesses | 198d? | 2006-12-01 A | 2007-09-04 | 15% | 168.3d? | 2006-12-01 | 2007-09-04 | 198d? | 409d | start no earlier than 2006-12-01 | S2 | 1584h | 237.6h | SAES-non_3GPP | Irfan Ali (Motorola) | Irfan.Ali@motorola.com | Rel-8 | Maurice |  |
| 58 | 6.6 | Deleted: Stage 2 of architecture for the 3GPP System Architecture Evolution | 290d? | 2007-02-05 A | 2008-03-14 | 4% | 279.7d? | 2006-12-01 | 2007-09-14 | 206d? | 271d |  | S2 | 2320h | 82.4h | SAES-St2 | Chris Pudney (Vodafone) | chris.pudney@vodafone.com | Rel-8 | Maurice | SP-34 |
| 59 | 7 | GERAN support for GERAN - 3G Long Term Evolution interworking | 376d? | 2006-09-08 A | 2008-02-15 | 20% | 300.8d? | 2006-09-08 | 2008-02-15 | 376d? | 291d | finish no earlier than 2008-02-15 | GP | 3008h | 601.6h | GELTE | Han van Bussel, T-Mobile | han.van.bussel@t-mobile.de | Rel-8 | Paolo |  |

Notes:
- 30: CT wide WID approved ib CT#34 / Text3: 24.8yz, 29.8ab, 29.8cd
- 40: 08/03/2007 08:00
- 41: 08/03/2007 08:00
- 42: 08/03/2007 08:00
- 56: SP-34: GPRS enhancements for LTE access item created. / Text3: 23.401
- 57: SP-34: Architecture enhancements for non-3GPP accesses item created. / Text3: 23.402
- 58: THIS LINE IS DELETED, replaced by the 2 Architecture parallel tracks. / Text3: 23.002, 23.060, 23.107, 23.203, 23.228, 23.234, 23.246, 23.271, 23.279
- 59: Text3: 24.008, 43.055, 43.129, 43.246, 44.018, 44.060, 45.002, 45.008, 45.010, 48.008,48.018, 51.010

| ID | WBS | Task | Type | Duration | Start | Finish | Complete | Remaining | Baseline start | Baseline finish | Baseline duration | Total slack | Constraint | Resources | Work | Actual work | Text1 | Text4 | Text6 | Text3 | Text5 | Text8 | Text7 |
| --- | --- | --- | --- | --- | --- | --- | --- | --- | --- | --- | --- | --- | --- | --- | --- | --- | --- | --- | --- | --- | --- | --- | --- |
| 60 | 8 | **Contact Manager for 3GPP UICC applications** |  | 447d? | 2006-06-22 A | 2008-03-07 | 2% | 436.3d? | 2006-06-22 | 2007-06-21 | 261d? | 276d |  | C6 | 6952h | 80.8h | eUPHBOOK | Claus Dietze (Giesecke & Devrient) | Rel-8 |  |  |  |  |
| 61 | 8.1 | Requirements for Contact Manager |  | 202d? | 2006-06-22 A | 2007-03-30 | 5% | 191.9d? | 2006-06-22 | 2006-12-21 | 131d? | 521d | finish no earlier than 2007-03-30 | C6 | 1616h | 80.8h | eUPHBOOK-St1 | Claus Dietze (Giesecke & Devrient) | Rel-8 | 21.111 |  |  |  |
| 62 | 8.2 | Specification of technical solution for the enhanced phonebook |  | 220d? | 2007-05-07 | 2008-03-07 |  |  | 2006-06-22 | 2006-12-21 | 131d? | 276d | finish no earlier than 2008-03-07 | C6 | 1760h |  | eUPHBOOK-Spec | Claus Dietze (Giesecke & Devrient) | Rel-8 | 31.xyz |  |  |  |
| 63 | 8.3 | Deleted - Implementation of eUPHBOOK | milestone | 0d? | 2007-06-21 | 2007-06-21 |  |  | 2006-06-22 | 2007-06-21 | 261d? | 462d | start no earlier than 2007-06-21 | C6 |  |  | eUPHBOOK-St23 |  | Rel-8 | 31.102 |  |  |  |
| 64 | 9 | **Enhancements for VGCS Applications** |  | 438d? | 2006-03-15 A | 2007-11-16 | 45% | 242.98d? | 2006-03-15 | 2007-11-16 | 438d? | 356d |  | S1 | 12176h | 4014.08h | EVA | Amar Deol, Nortel Networks | Rel-8 | 42.068 | deola@nortel.com | Michael |  |
| 65 | 9.1 | SA1 aspects for EVA |  | 191d? | 2006-03-15 A | 2006-12-06 A | 100% |  | 2006-03-15 | 2006-12-06 | 191d? |  | finish no earlier than 2006-12-06 | S1 | 1528h | 1528h | EVA-s1 | Amar Deol, Nortel Networks | Rel-8 | 42.068 | deola@nortel.com | Michael |  |
| 66 | 9.2 | C1 aspects for EVA |  | 271d? | 2006-06-02 A | 2007-06-15 | 50% | 135.5d? | 2006-06-02 | 2007-06-15 | 271d? | 466d | finish no earlier than 2007-06-15 | C1 | 2168h | 1084h | EVA | Milan Patel | Rel-8 | 43.068, 44.068 | milanpa@nortel.com | Andrijana |  |
| 67 | 9.3 | C4 aspects for EVA |  | 261d? | 2006-06-02 A | 2007-06-01 | 46% | 140.94d? | 2006-06-02 | 2007-03-09 | 201d? | 476d | finish no earlier than 2007-06-01 | C4 | 2088h | 960.48h | EVA-c4 |  | Rel-8 | 29.002 |  | Kimmo |  |
| 68 | 9.4 | GERAN2 Aspects of EVA |  | 361d? | 2006-06-30 A | 2007-11-16 | 10% | 324.9d? | 2006-06-30 | 2007-11-16 | 361d? | 356d | finish no earlier than 2007-11-16 | G2 | 2888h | 288.8h | EVA-EVGCSA | Frank Billenkamp (Notrtel Networks) | Rel-8 | 44.018, 48.008 | frank.billenkamp@nortel.com | Gert |  |
| 69 | 10 | **IMS Service Brokering enhancements** |  | 69d? | 2005-12-07 A | 2006-03-13 A | 100% |  | 2005-12-07 | 2006-03-13 | 69d? |  |  | S1 | 1104h | 1104h | ISB | John-Luc Bakker (Telcordia) | Rel-8 | 22.228 | jbakker@telcordia.com | Michael |  |
| 70 | 10.1 | Stage 1 of ISB |  | 69d? | 2005-12-07 A | 2006-03-13 A | 100% |  | 2005-12-07 | 2006-03-13 | 69d? |  | finish no earlier than 2006-03-13 | S1 | 552h | 552h | ISB-s1 | John-Luc Bakker (Telcordia) | Rel-8 | 22.228 | jbakker@telcordia.com | Michael |  |
| 71 | 11 | **Multimedia Priority Service** |  | 337d? | 2006-06-08 A | 2007-09-21 | 68% | 106.4d? | 2006-06-08 | 2007-09-21 | 337d? | 396d |  | S1 | 7072h | 4338.4h | PRIOR | Jim Garrahan (Telcordia) | Rel-8 | 22.153 | jgarraha@telcordia.com | Michael |  |
| 72 | 11.1 | Service Requirements for PRIOR |  | 336d? | 2006-06-08 A | 2007-09-20 | 80% | 67.2d? | 2006-06-08 | 2007-09-20 | 336d? | 397d | finish no earlier than 2007-09-20 | S1 | 2688h | 2150.4h | PRIOR-EMR | Jim Garrahan (Telcordia) | Rel-8 | 22.153 | jgarraha@telcordia.com | Michael |  |
| 73 | 11.2 | Multimedia Priority Service for PRIOR - Stage 3 |  | 211d? | 2006-12-01 A | 2007-09-21 | 50% | 105.5d? | 2006-12-01 | 2007-09-21 | 211d? | 396d | finish no earlier than 2007-09-21 | C1 | 1688h | 844h | PRIOR-MM | Keith Drage, Alcatel-Lucent | Rel-8 | 24.229 | drage@Alcatel-Lucent.com | Andrijana |  |
| 74 | 12 | eCall Data Transfer – Requirements |  | 51d? | 2006-09-28 A | 2006-12-07 A | 100% |  | 2006-09-28 | 2006-12-07 | 51d? |  | finish no earlier than 2006-12-07 | S1 | 408h | 408h | EData | Rhys Robinson (Airbiquity) | Rel-8 | 22.101, 22.105 | rrobinson@airbiquity.com | Maurice |  |
| 75 | 13 | Local Charging Zone Requirements |  | 51d? | 2006-09-28 A | 2006-12-07 A | 100% |  | 2006-09-28 | 2006-12-07 | 51d? |  | finish no earlier than 2006-12-07 | S1 | 408h | 408h | LCZR | Hong Liu (China Mobile) | Rel-8 | 22.115 | liuhongyfw@chinamobile.com | Michael |  |
| 76 | 14 | Enhancements to BS30 Bearer service for Videotelephony |  | 51d? | 2007-01-04 A | 2007-03-15 | 10% | 45.9d? | 2007-01-04 | 2007-03-15 | 51d? | 532d | finish no earlier than 2007-03-15 | S1 | 408h | 40.8h | BS30 | Andre Jarvis (3) | Rel-8 | 22.002, 22.004, 22.101, 22.105, 24.008 | andre.jarvis@three.co.uk | Michael |  |
| 77 | 15 | Deleted (never approved) FBI Phase 2 |  | 349d? | 2006-06-30 | 2007-10-31 |  |  | 2006-06-30 | 2007-10-31 | 349d? | 368d | start no earlier than 2006-06-30 | S2 | 2792h |  | FBI2 |  | Rel-8 |  |  | Maurice | TSG |
| 78 | 16 | **System enhancements for interconnection interfaces between two IMSs** |  | 468d? | 2006-08-16 A | 2008-05-30 | 9% | 423.65d? | 2006-06-30 | 2007-10-31 | 349d? | 216d |  | S2 | 8712h | 728.75h | FBI2-TISP2 | Steve Tsang-Kwong-U, Orange | Rel-8 |  |  |  |  |
| 79 | 16.1 | IMS inter-operator service interconnection interface |  | 261d? | 2007-06-01 | 2008-05-30 |  |  |  |  |  | 216d | finish no earlier than 2008-05-30 | C3 | 2088h |  | FBI2-IOPSI | Mauro Ficaccio (Telecom Italia) | Rel-8 | 29.abc, 29.def | mauro.ficaccio@telecomitalia.it | Seung Don |  |
| 80 | 16.2 | Charging harmonization for NGN between 3GPP and ATIS-TMOC |  | 51d? | 2006-09-28 A | 2006-12-07 A | 100% |  | 2006-09-28 | 2006-12-07 | 51d? |  | finish no earlier than 2006-12-07 | S5 | 408h | 408h | FBI2-TISP2-CH | Amdocs | Rel-8 | 32.297 | yishai.brown@amdocs.com | Adrian |  |
| 81 | 16.3 | Protocol impact of FBI for TISPAN R2 |  | 152d? | 2006-08-16 | 2007-03-15 |  |  | 2006-08-16 | 2007-03-15 | 152d? | 532d | finish no earlier than 2007-03-15 | C1 | 1216h |  | FBI2-TISP2-c1 |  | Rel-8 |  |  |  |  |
| 82 | 16.4 | Deleted (never approved) - Stage 2 of FBI for TISPAN R2 - Rel 8 |  | 157d? | 2007-04-26 A | 2007-11-30 | 5% | 149.15d? | 2006-06-30 | 2007-10-31 | 349d? | 346d | start no earlier than 2007-04-26 | S2 | 1256h | 62.8h | FBI2-TISP2-s2 |  | Rel-8 |  |  |  |  |
| 83 | 17 | IMS System enhancements for corporate network access |  | 131d? | 2007-06-22 | 2007-12-21 |  |  |  |  |  | 331d | finish no earlier than 2007-12-21 | S2 | 1048h |  | IMSCorp | Steve Tsang-Kwong-U, Orange | rel-8 |  |  |  |  |

Notes:
- 60: Moved from Rel-7 to Rel-8 at CT#33. C6-43: WI Name change to Enhanced USIM Phonebook. Completion date updated to 03/2008. Supporting Members: Giesecke & Devrient, T-Mobile, SagemOrga, Oberthur, Gemalto, Telefonica, ST Incard, Microelectronica, Cingular, O
- 61: C6-43: Name Changed to Requirements for Contact Manager. Expected completion updated from CT#34 to CT#35.
- 62: New TS 31.xyz to be produced
- 67: CT4#32: Crs are presented and in principle agreed, waiting for the approval of stage2...
- 71: Created by MCC to group 320023 (Stage 1) and 340012 (Stage 3) wrongly shown as idependent Features
- 72: Official name is "Multimedia Priority Service" but this is identical to UID 31041
- 73: "CT1" corrected into "C1"
- 77: Added by MCC as a consequence of the move to Rel8 of TISPAN Rel-2 impacts on 3GPP
- 78: Name changed from "System enhancements for TISPAN Rel2" at SA36
- 79: Approved at CT#36
- 80: 09/2006 SA#33 WID approved
- 82: It might be more appropriate to introduce the individual functions instead of a global title. SA2 WID expected at SA#36

| ID | WBS | Task | Type | Duration | Start | Finish | Complete | Remaining | Baseline start | Baseline finish | Baseline duration | Total slack | Constraint | Resources | Work | Actual work | Text1 | Text6 | Text3 | Text4 | Text5 | Text8 |
| --- | --- | --- | --- | --- | --- | --- | --- | --- | --- | --- | --- | --- | --- | --- | --- | --- | --- | --- | --- | --- | --- | --- |
| 84 | 18 | **IMS Enhancements for support of Packet Cable access** |  | 272d? | 2006-12-06 A | 2007-12-20 | 35% | 177.67d? |  |  |  | 332d |  | S2 | 18288h | 5482.28h | PktCbl | Rel-8 |  |  |  |  |
| 85 | 18.1 | **IMS Enhancements for Security Requirements in Support of Cable Deployments** |  | 272d? | 2006-12-06 A | 2007-12-20 | 22% | 213.47d? | 2006-12-06 | 2007-12-20 | 272d? | 332d |  | S3 | 7232h | 1088h | PktCbl-Sec | Rel-8 | 33.203, 33.210, 33.220, 24.229 | Steve Dotson (Cablelabs) | s.dotson@cablelabs.com | Michael |
| 86 | 18.1.1 | S3 Aspects of PktCbl-Sec |  | 272d? | 2006-12-06 A | 2007-12-20 | 50% | 136d? | 2006-12-06 | 2007-12-20 | 272d? | 332d | finish no earlier than 2007-12-20 | S3 | 2176h | 1088h | PktCbl-Sec | Rel-8 | 33.203, 33.210, 33.220, 24.229 | Steve Dotson (Cablelabs) | s.dotson@cablelabs.com | Michael |
| 87 | 18.1.2 | CT1 Aspects of PktCbl-Sec |  | 180d? | 2007-03-26 | 2007-11-30 |  |  |  |  |  | 346d | start no earlier than 2007-03-26 | C1 | 1440h |  | PktCbl-Sec | Rel-8 | 24.229, 24.109 | David Hancock (CableLabs) | D.Hancock@ CableLabs.com | Andrijana |
| 88 | 18.1.3 | CT4 Aspects of PktCbl-Sec |  | 180d? | 2007-03-26 | 2007-11-30 |  |  |  |  |  | 346d | start no earlier than 2007-03-26 | C4 | 1440h |  | PktCbl-Sec | Rel-8 | 29.228, 29229, 23.008, | David Hancock (CableLabs) | D.Hancock@ CableLabs.com | Kimmo |
| 89 | 18.2 | **IMS Enhancements for Cable Client Types and Deployment Models** |  | 215d? | 2007-02-05 A | 2007-11-30 | 7% | 199.82d? |  |  |  | 346d |  | S2 | 4440h | 394.35h | PktCbl-Deploy | Rel-8 |  |  |  |  |
| 90 | 18.2.1 | Architecture aspects of PktCbl-Deploy |  | 160d? | 2007-02-05 A | 2007-09-14 | 15% | 136d? |  |  |  | 401d | start no earlier than 2007-02-05 | S2 | 1280h | 192h | PktCbl-Deploy | Rel-8 |  |  |  |  |
| 91 | 18.2.2 | CT1 aspects of PktCbl-Deploy |  | 180d? | 2007-03-26 | 2007-11-30 |  |  |  |  |  | 346d | start no earlier than 2007-03-26 | C1 | 1440h |  | PktCbl-Deploy | Rel-8 | 24.229, 24167 | David Hancock (CableLabs) | D.Hancock@ CableLabs.com | Andrijana |
| 92 | 18.3 | **IMS Inter-working Aspects in Support of Cable Regulatory requirements** |  | 215d? | 2007-02-05 A | 2007-11-30 | 87% | 28.46d? |  |  |  | 346d |  | S2 | 4440h | 3245.29h | PktCbl-Intw | Rel-8 | 23.228 | Bernie McKibben (CableLabs) | B.McKibben@CableLabs.com | Maurice |
| 93 | 18.3.1 | Architecture aspects of PktCbl-Interwork |  | 160d? | 2007-02-05 A | 2007-09-14 A | 100% |  |  |  |  |  | start no earlier than 2007-02-05 | S2 | 1280h | 1280h | PktCbl-Intw | Rel-8 | 23.228 | Bernie McKibben (CableLabs) | B.McKibben@CableLabs.com | Maurice |
| 94 | 18.3.2 | CT1 aspects of PktCbl-Interwork |  | 180d? | 2007-03-26 A | 2007-11-30 | 75% | 45d? |  |  |  | 346d | start no earlier than 2007-03-26 | C1 | 1440h | 1080h | PktCbl-Intw | Rel-8 | 24.229 | David Hancock (CableLabs) | D.Hancock@ CableLabs.com | Andrijana |
| 95 | 19 | Services Alignment and Migration |  | 256d? | 2006-12-06 A | 2007-11-28 | 65% | 89.6d? | 2006-09-28 | 2007-09-20 | 256d? | 348d | finish no earlier than 2007-09-20 | S1 | 2048h | 1331.2h | ServAl | Rel-8 | 22.182 | Feng Lingjuan (China Mobile) | (fenglingjuan@chinamobile.com) | Michael |
| 96 | 20 | Support of Customised Alerting Tone Service |  | 207d? | 2006-12-06 A | 2007-09-20 | 80% | 41.4d? | 2006-12-06 | 2007-09-20 | 207d? | 397d | finish no earlier than 2007-09-20 | S1 | 1656h | 1324.8h | CusAlert | Rel-8 | 22.182 | Feng Lingjuan (China Mobile) | (fenglingjuan@chinamobile.com) | Michael |
| 97 | 21 | I-WLAN NSP |  | 6d? | 2006-12-06 A | 2006-12-13 | 70% | 1.8d? | 2006-12-06 | 2006-12-13 | 6d? | 598d | finish no earlier than 2006-12-13 | S1 | 48h | 33.6h | IWLANNSP | Rel-8 | 22.234 | Chris Friel (O2) | chris.friel@o2.com | Michael |
| 98 | 22 | **Support of Service-Level Interworking for Messaging Services** |  | 195d? | 2007-03-26 A | 2007-12-24 | 14% | 168.29d? | 2006-12-06 | 2007-06-07 | 132d? | 330d |  | S1 | 2944h | 1245.6h | MESSIW | Rel-8 | 22.105, 22.340 | Liu Ling (Huawei) | ling.liu@huawei.com | Michael |
| 99 | 22.1 | Stage 1 aspects of Service-Level Interworking for Messaging Services | milestone | 0d? | 2007-03-26 A | 2007-03-26 A | 100% |  | 2006-12-06 | 2007-06-07 | 132d? |  | finish no earlier than 2007-12-01 | S1 |  |  | MESSIW-St1 | Rel-8 | 22.105, 22.340 | Liu Ling (Huawei) | ling.liu@huawei.com | Michael |
| 100 | 22.2 | Stage 2 aspects of Service-Level Interworking for Messaging Services |  | 173d? | 2007-04-26 A | 2007-12-24 | 14% | 149.3d? | 2006-12-06 | 2007-06-07 | 132d? | 330d | finish no earlier than 2007-12-21 | S2 | 1384h | 189.6h | MESSIW-St2 | Rel-8 | TR 23.abc, TS 23.xyz, 22.105, 22.340 | Duan Xiaoqin (Huawei) | duanxiaoqin@huawei.com | Maurice |
| 101 | 23 | **OAM&P 8 (not yet official)** |  | 857d? | 2005-09-02 A | 2008-12-15 | 22% | 671.74d? |  |  |  | 75d |  | S5 | 40351.1h | 5909.6h | OAM8 | Rel-8 |  |  |  | Adrian |
| 102 | 23.1 | **Network Infrstructure Management 8** |  | 857d? | 2005-09-02 A | 2008-12-15 | 18% | 700.54d? |  |  |  | 75d |  | S5 | 22398h | 3278.8h | OAM8-NIM | Rel-8 |  |  |  | Adrian |
| 103 | 23.1.1 | Integration Reference Point (IRP) Methodology |  | 857d? | 2005-09-02 A | 2008-12-15 | 20% | 685.6d? | 2005-09-02 | 2008-12-15 | 857d? | 75d | finish no earlier than 2008-12-15 | S5 | 6856h | 1371.2h | OAM8-NIM | Rel-8 | TS 32.155 | Ericsson |  | Adrian |
| 104 | 23.1.2 | Advanced Alarming on Itf-N (Study + Implementation) |  | 596d? | 2005-09-02 A | 2007-12-14 | 20% | 476.8d? | 2005-09-02 | 2007-06-14 | 465d? | 336d | finish no earlier than 2007-12-14 | S5 | 4768h | 953.6h | OAM8-NIM | Rel-8 | TS 32.121/2/3/5 | Siemens |  | Adrian |
| 105 | 23.1.3 | CN CS Bearer Transport Network (BTN) relative NRM |  | 596d? | 2005-09-02 A | 2007-12-14 | 20% | 476.8d? | 2005-09-02 | 2007-03-15 | 400d? | 336d | finish no earlier than 2007-12-14 | S5 | 4768h | 953.6h | OAM8-NIM | Rel-8 | 32.74x | China Mobile |  | Adrian |
| 106 | 23.1.4 | HSUPA performance measurements |  | 196d? | 2007-06-07 A | 2008-03-06 |  | 195.95d? |  |  |  | 277d | finish no earlier than 2008-03-06 | S5 | 1568h | 0.4h | OAM8-NIM | Rel-8 | 32.405 | China Mobile |  |  |
| 107 | 23.2 | **Performance Management 8** |  | 655d? | 2005-09-02 A | 2008-03-06 | 41% | 383.86d? |  |  |  | 277d |  | S5 | 9816h | 2622.8h |  | Rel-8 |  |  |  | Adrian |
| 108 | 23.2.1 | IP bearer network Performance measurement definitions |  | 596d? | 2005-09-02 A | 2007-12-14 | 55% | 268.2d? | 2005-09-02 | 2007-03-15 | 400d? | 336d | finish no earlier than 2007-12-14 | S5 | 4768h | 2622.4h | OAM7-PM | Rel-8 | 32.404,32.405,32.406,32.407 | China Mobile |  | Adrian |
| 109 | 23.2.2 | Key Performance Indicator |  | 196d? | 2007-06-07 A | 2008-03-06 |  | 195.95d? |  |  |  | 277d | finish no earlier than 2008-03-06 | S5 | 1568h | 0.4h |  | Rel-8 | 32.405 | China Mobile |  |  |
| 110 | 23.3 | Deleted - Trace Management 8 |  | 1d? | 2007-06-22 A | 2007-06-22 A | 100% |  |  |  |  |  | start no earlier than 2007-06-22 | S5 | 8h | 8h |  | Rel-8 |  |  |  |  |
| 111 | 23.4 | Service Level Tracing in IMS |  | 379.14d? | 2006-09-22 A | 2008-04-10 |  | 379.14d? | 2006-09-22 | 2007-06-08 | 179.14d? | 252.04d | finish no earlier than 2008-03-15 | C1 | 3033.12h |  | OAM7-Trace | Rel-8 | 24.229, 24.167, 29.228,29.229,29.163,29.332 | Jari Jansson, Nokia | jari.jansson@nokia.com | Andrijana |
| 112 | 24 | Registration in Densely-populated area |  | 4d? | 2007-03-12 A | 2007-03-15 | 90% | 0.4d? |  |  |  | 532d | start no earlier than 2007-03-12 | S1 | 32h | 28.8h | RED | Rel-8 | 22.101 | Tsuyoshi Takakura (NTT DoCoMo Inc.) | takakurat@s1.nttdocomo.co.jp | Michael |
| 113 | 25 | Lawful Interception in the 3GPP Rel-8 |  | 265d? | 2007-03-12 A | 2008-03-14 | 20% | 212d? |  |  |  | 271d | finish no earlier than 2008-03-14 | S3 | 2120h | 424h | LI8 | Rel-8 | 33.106, 33.107, 33.108 | Berthold Wilhelm (BMWi/BNetzA) | berthold.wilhelm@bnetza.de | Michael |

Notes:
- 87: Supporting Companies:
- 88: Supporting Companies:
- 91: Supporting Companies:
- 92: Supporting Companies: CableLabs, Nortel, Cisco, Samsung, Alcatel-Lucent, Siemens, Motorola, Hewlett-Packard, Ericsson
- 93: Supporting Companies: CableLabs, Nortel, Cisco, Samsung, Alcatel-Lucent, Siemens, Motorola, Hewlett-Packard, Ericsson
- 94: Supporting Companies:
- 95: previous names were Services Alignment, Service Migration
- 100: WID Updated S2-57
- 101: Created to encompass the Rel7 Work Tasks shifted to Rel8
- 102: Created to encompass the Rel7 Work Tasks shifted to Rel8
- 103: Request to TSG#35 to move to Release 8
- 104: Request to TSG#35 to move to Release 8
- 105: Request to TSG#35 to move to Release 8
- 107: Created to encompass the Rel7 Work Tasks shifted to Rel8
- 108: Request to TSG#35 to move to Release 8
- 110: Created to encompass the Rel7 Work Tasks shifted to Rel8
- 111: Request to TSG#35 to move to Release 8
- 112: One CR at SA #35
- 113: End date to be determined when Rel-8 frozen.

| ID | WBS | Task | Duration | Start | Finish | Complete | Remaining | Baseline start | Baseline finish | Baseline duration | Total slack | Constraint | Resources | Work | Actual work | Text1 | Text6 | Text8 | Text4 | Text5 | Text7 | Text12 |
| --- | --- | --- | --- | --- | --- | --- | --- | --- | --- | --- | --- | --- | --- | --- | --- | --- | --- | --- | --- | --- | --- | --- |
| 114 | 26 | **Rel-8 Improvements of the Radio Interface** | 215d? | 2007-03-05 A | 2007-12-28 | 20% | 172.27d? | 2004-09-15 | 2007-06-15 | 718d? | 326d |  | RP | 7840h | 2056h | RInImp8 | Rel-8 | Claude |  |  |  |  |
| 115 | 26.1 | UMTS 1500 MHz | 140d? | 2007-03-05 A | 2007-09-14 | 50% | 70d? | 2004-09-15 | 2005-06-14 | 195d? | 401d | finish no earlier than 2007-09-14 | R4 | 1120h | 560h | RInImp8-UMTS1500 | Rel-8 | Claude | Takehiro Nakamura | NTT DoCoMo | TSG |  |
| 116 | 26.2 | UMTS 700 MHz | 215d? | 2007-03-05 A | 2007-12-28 | 20% | 172d? | 2004-09-15 | 2005-06-14 | 195d? | 326d | start no earlier than 2007-03-05 | R4 | 1720h | 344h | RInImp8-UMTS700 | Rel-8 | Claude | Tuomo Saynajakangas | Nokia | TSG |  |
| 117 | 26.3 | UMTS 2300 MHz | 215d? | 2007-03-05 | 2007-12-28 |  |  | 2004-09-15 | 2005-06-14 | 195d? | 326d | start no earlier than 2007-03-05 | R4 | 1720h |  | RInImp8-UMTS2300 | Rel-8 | Claude | Marc Grant | marc.grant@cingular.com | TSG |  |
| 118 | 26.4 | Further Improved Minimum Performance Requirements for HSDPA UE (FDD) - Two-Branch Interference Cancellation | 215d? | 2007-03-05 A | 2007-12-28 | 20% | 172d? | 2005-12-15 | 2007-03-15 | 326d? | 326d | finish no earlier than 2007-12-28 | R4 | 1720h | 344h | RInImp8-2BIC | Rel-8 | MCC_RAN | Marc Grant, Cingular | marc.grant@cingular.com |  |  |
| 119 | 27 | **Personal Network Management** | 971d? | 2005-07-11 A | 2009-03-30 | 24% | 737.94d? | 2005-07-11 | 2007-10-30 | 601.6d? | 0d |  | S1 | 23492.8h | 5409.51h | PNM | Rel-8 | Mike | Armin Toepfer, Vodafone | armin.toepfer@vodafone.com |  |  |
| 120 | 27.1 | Stage 1 of PNM | 276d? | 2005-07-11 A | 2006-07-31 | 85% | 41.4d? | 2005-07-11 | 2006-07-31 | 276d? | 695d | start no earlier than 2005-07-11 | S1 | 2208h | 1876.8h | PNM | Rel-8 |  |  |  |  |  |
| 121 | 27.2 | Actual Requirements of PNM | 526d? | 2007-03-26 | 2009-03-30 |  |  |  |  |  | 0d | start no earlier than 2007-03-26 | C1 | 4208h |  | PNM | Rel-8 |  | Yang Lu, |  |  |  |
| 122 | 27.3 | Stage 2 of PNM | 526d? | 2007-03-26 A | 2009-03-30 | 40% | 315.6d? |  |  |  | 0d | finish no earlier than 2009-03-30 | C1 | 4208h | 1683.2h | PNM | Rel-8 |  | Yang Lu, |  |  |  |
| 123 | 27.4 | **Stage 3 of PNM** | 263d? | 2007-03-26 | 2008-03-26 |  |  | 2005-07-11 | 2006-07-31 | 276d? | 263d |  | C1 | 5163.2h |  | PNM | Rel-8 |  | Yang Lu, |  |  |  |
| 124 | 27.4.1 | CT1 aspects of PNM | 263d? | 2007-03-26 | 2008-03-26 |  |  |  |  |  | 263d | start no earlier than 2007-03-26 | C1 | 2104h |  | PNM | Rel-8 |  | Yang Lu, |  |  |  |
| 125 | 27.4.2 | CT4 aspects of PNM | 263d? | 2007-03-26 | 2008-03-26 |  |  |  |  |  | 263d | start no earlier than 2007-03-26 | C4 | 2104h |  | PNM | Rel-8 |  | Yang Lu, |  |  |  |
| 126 | 28 | GAN Enhancements | 206d? | 2006-11-17 A | 2007-08-31 | 90% | 20.6d? |  |  |  | 411d | start no earlier than 2006-11-17 | GP | 1648h | 1483.2h | EGAN | Rel-8 | Paolo | Janne Linkola (T-Mobile) | janne.linkola@t-mobile.com |  |  |
| 127 | 29 | **Charging Management small Enhancements** | 420d? | 2006-05-08 A | 2007-12-14 | 10% | 377.5d? | 2006-05-22 | 2007-03-15 | 214d? | 336d |  | S5 | 6648h | 345.47h | CH8 | Rel-8 | Adrian | Orange |  |  |  |
| 128 | 29.1 | Online charging correlation | 420d? | 2006-05-08 A | 2007-12-14 | 10% | 378d? | 2006-05-22 | 2007-03-15 | 214d? | 336d | finish no earlier than 2007-12-14 | S5 | 3360h | 336h |  | Rel-8 |  | Orange | alain.bibas@orange-ft.com |  |  |
| 129 | 29.2 | SMS online charging | 1d? | 2007-04-02 A | 2007-04-02 | 60% | 0.4d? |  |  |  | 520d |  | S5 | 8h | 4.8h |  | Rel-8 |  | Vodafone |  |  |  |
| 130 | 30 | **OSA Rel-8** | 336d? | 2007-08-23 | 2008-12-04 |  |  | 2005-03-15 | 2007-06-09 | 584d? | 82d |  | S1 | 5016h |  | OSA8 | Rel-8 | Michael | Orange |  | TSG |  |
| 131 | 30.1 | OSA Stage 1 - Service Requirements | 336d? | 2007-08-23 | 2008-12-04 |  |  | 2005-03-15 | 2005-06-08 | 62d? | 82d | finish no earlier than 2008-12-04 | S1 | 2688h |  | OSA8 | Rel-8 | Michael |  |  | TSG |  |
| 132 | 30.2 | OSA Stage 2/3 enhancements | 291d? | 2007-10-25 | 2008-12-04 |  |  | 2006-04-28 | 2007-06-09 | 291d? | 82d | finish no earlier than 2008-12-04 | C5 | 2328h |  | OSA8 | Rel-8 | Adrian | Orange |  |  |  |
| 133 | 31 | Combination of 64QAM and MIMO for HSDPA (FDD) | 201d? | 2007-06-04 | 2008-03-10 |  |  |  |  |  | 275d | finish no earlier than 2008-03-10 | R1 | 1608h |  | RANimp-64QamMimoHsdpa | Rel-8 | MCC_RAN | Johan Bergman, Ericsson | Johan.Bergman@ericsson.com |  |  |
| 134 | 32 | (Small) Technical Enhancements and Improvements for Rel-8 | 400d? | 2007-01-01 | 2008-07-11 |  |  | 2007-01-01 | 2008-07-11 | 400d? | 186d | start no earlier than 2007-01-01 | All | 3200h |  | TEI8 | Rel-8 |  |  |  |  |  |
| 135 | 33 | Delete - was a Rel7 item - LCS for 3GPP Interworking WLAN | 245d? | 2006-10-23 | 2007-09-28 |  |  | 2006-10-23 | 2007-09-28 | 245d? | 391d | finish no earlier than 2007-09-28 | S2 | 1960h |  | LCS4_IWLAN | Rel-8 | Maurice | Donghee Shim (LG Electronics Inc.) | dhshim@lge.com |  | S2-56 |
| 136 | 34 | Rel-8 Feasibility Studies | 1d? | 2000-01-03 | 2000-01-03 |  |  | 2000-01-03 | 2000-01-03 | 1d? | 2410d |  | CT;RAN;SA | 8h |  |  | Rel-8 |  |  |  |  |  |
| 137 | 35 | Study on Facilitating Machine to Machine Communication in GSM and UMTS (M2M) | 161d? | 2005-11-04 A | 2006-06-16 | 90% | 16.1d? | 2005-11-04 | 2006-06-16 | 161d? | 726d | finish no earlier than 2006-06-16 | S1 | 1288h | 1159.2h | M2M | Rel-8 | Michael | Juergen Merkel, Siemens AG |  |  |  |
| 138 | 36 | FS on Network Composition | 211d? | 2005-12-07 A | 2006-09-27 | 90% | 21.1d? | 2005-12-07 | 2006-09-27 | 211d? | 653d | finish no earlier than 2006-09-27 | S1 | 1688h | 1519.2h | NetComp | Rel-8 |  | Joerg Swetina (Siemens) | joerg.swetina@siemens.com |  |  |
| 139 | 37 | Study on Charging Aspects of 3GPP System Evolution | 179d? | 2007-04-02 A | 2007-12-06 | 20% | 143.2d? | 2006-05-10 | 2008-12-15 | 679d? | 342d | finish no earlier than 2007-12-06 | S5 | 1432h | 286.4h | FSSAEcharg | Rel-8 |  | Siemens | gerald.goermer@siemens.com |  | SP-32 |

Notes:
- 115: Text3: TS25.101, TS25.104, TS25.133, TS25.141, TS25.331, TS25.942, TS25.306, TS25.307, TS34.121
- 116: Text3: TS25.101, TS25.104, TS25.133, TS25.141, TS25.331, TS25.942, TS25.306, TS25.307, TS34.121
- 117: Text3: TS25.101, TS25.104, TS25.133, TS25.141, TS25.331, TS25.942, TS25.306, TS25.307, TS34.121
- 119: Moved from FS section Feb 06. SP-33: Create new section to capture the PNM stage 2 aspects and identify any impacts to existing stage 2 specifications. S2 added as secondary responsibility
- 120: Moved from FS section Feb 06: SP-33: Create new section to capture the PNM stage 2 aspects and identify any impacts to existing stage 2 specifications. / Text3: 22.259, 23.818
- 123: Moved from FS section Feb 06: SP-33: Create new section to capture the PNM stage 2 aspects and identify any impacts to existing stage 2 specifications.
- 124: Text3: 24.229
- 125: Text3: 23.008, 23.018, 29.002, 29.328, 29.329
- 126: Moved from Rel7 / Text3: 43.902
- 127: Text3: 32.2xy
- 128: WID approved SA#35 / Text3: 32.240, 32.296
- 129: Text3: TS 32.274, CR 32.240 / 299/ 298
- 131: az: WID URL corrected / Text3: 22.127
- 132: CT#34: WID updated. Completion 12/06 =>03/07 / Text3: 23.198, 29.198/9
- 133: Text3: 25.308,25.211,25.212,25.213,25.306,25.331,25.433,25.435,25.423,25.425,25.101,25.104,25.141
- 135: New WID approved SP-34. Supporting companies: Telcordia, Samsung, Qualcomm, BT, LG Electronics, Cingular, Alcatel-Lucent. No scheduled end date! / Text3: 23.234, 23.271, 23.167
- 137: Text3: 22.868
- 138: Text3: 22.980
- 139: WID approved SA#35 / Text3: TR 32.820

| ID | WBS | Task | Duration | Start | Finish | Complete | Remaining | Baseline start | Baseline finish | Baseline duration | Total slack | Constraint | Resources | Work | Actual work | Text1 | Text3 | Text4 | Text5 | Text6 | Text7 | Text8 | Text12 |
| --- | --- | --- | --- | --- | --- | --- | --- | --- | --- | --- | --- | --- | --- | --- | --- | --- | --- | --- | --- | --- | --- | --- | --- |
| 140 | 38 | **All-IP Network (AIPN)** | 448d? | 2004-06-28 A | 2006-03-15 A | 100% |  | 2004-06-28 | 2006-03-15 | 448d? |  |  | S1 | 8672h | 8672h | AIPN | 22.978 | Chris Sachno (NTT DoCoMo) | c.masyu@nttdocomo.co.jp | Rel-8 | TSG | Michael |  |
| 141 | 38.1 | All-IP Network Feasibility Study | 188d? | 2004-06-28 A | 2005-03-16 A | 100% |  | 2004-06-28 | 2005-03-16 | 188d? |  | start no earlier than 2004-06-28 | S1 | 1504h | 1504h | AIPFS | 22.978 | Chris Sachno (NTT DoCoMo) | c.masyu@nttdocomo.co.jp | Rel-8 | TSG | Michael |  |
| 142 | 38.2 | Stage1 | 448d? | 2004-06-28 A | 2006-03-15 A | 100% |  | 2004-06-28 | 2006-03-15 | 448d? |  | finish no earlier than 2006-03-15 | S1 | 3584h | 3584h | AIPN | 22.258 | Chris Sachno (NTT DoCoMo) | c.masyu@nttdocomo.co.jp | Rel-8 | TSG | Michael |  |
| 143 | 39 | Study on Stage 2 aspects of IMS Service Brokering | 380d? | 2006-06-19 A | 2007-12-01 | 47% | 201.4d? | 2006-06-19 | 2007-06-22 | 265d? | 346d | finish no earlier than 2007-12-01 | S2 | 3040h | 1428.8h | ISB_ST2_SDY | 23.810 | Raquel Morera (Telcordia); F. Joe Lin (Telcordia) | raquel@research.telcordia.com | Rel-8 |  | Maurice |  |
| 144 | 40 | Study of Requirements of IMS Multimedia Conferencing | 205d? | 2006-06-08 A | 2007-03-21 | 70% | 61.5d? | 2006-06-08 | 2007-03-21 | 205d? | 528d | finish no earlier than 2007-03-21 | S1 | 1640h | 1148h | SI-IMSconf | 22.948 | Zheng Jianping (China Mobile ) | zhengjianping@chinamobile.com | Rel-8 |  | Michael |  |
| 145 | 41 | Study on support of a Public Warning System | 205d? | 2006-06-08 A | 2007-03-21 | 70% | 61.5d? | 2006-06-08 | 2007-03-21 | 205d? | 528d | start no earlier than 2006-06-08 | S1 | 1640h | 1148h | PWS-SI | 22.968 | Mark Young (T-mobile) | mark.younge@t-mobile.com | Rel-8 |  | Michael |  |
| 146 | 42 | Study on Protection against SMS and MMS spam | 402d? | 2006-06-08 A | 2007-12-21 | 10% | 361.8d? | 2006-06-08 | 2007-03-21 | 205d? | 331d | finish no earlier than 2007-12-21 | S3 | 3216h | 321.6h | CPSMal | 33.9xx | Eric Gauthier (Orange SA) | eric.gauthier@orange.ch | Rel-8 |  | Michael |  |
| 147 | 43 | Study of VCC support for Emergency Calls | 387d? | 2006-06-08 A | 2007-12-01 | 15% | 328.95d? | 2006-06-08 | 2007-03-23 | 207d? | 346d | finish no earlier than 2007-12-01 | S2 | 3096h | 464.4h | FSVCCEm | 23.826 | Bob Beeson, Alcatel-Lucent |  | Rel-8 |  | Maurice |  |
| 148 | 44 | Study on Centralised IMS Service Control | 290d? | 2006-10-23 A | 2007-12-01 | 60% | 116d? | 2006-10-23 | 2007-09-14 | 235d? | 346d | finish no earlier than 2007-12-01 | S2 | 2320h | 1392h | IMS_CSC | 23.892 | Andy Bennett (Alcatel-Lucent) | andybennett@Alcatel-Lucent.com | Rel-8 |  | Maurice |  |
| 149 | 45 | Study on IMS utilizing multicast bearer services | 398d? | 2006-03-22 A | 2007-09-28 | 75% | 99.5d? | 2006-03-22 | 2007-03-02 | 248d? | 391d | finish no earlier than 2007-09-28 | S2 | 3184h | 2388h | FS-MLTICAST-IMS | 23.847 | Fiona Zhu (Siemens AG) |  | Rel-8 |  | Maurice |  |
| 150 | 46 | Study on Paging Permission with Access Control | 256d? | 2006-09-28 A | 2007-09-20 | 80% | 51.2d? | 2006-09-28 | 2007-09-20 | 256d? | 397d | finish no earlier than 2007-09-20 | S1 | 2048h | 1638.4h | PPAC | 22.908 | Katsuhiro Noguchi (NTT DoCoMo Inc.) | noguchi@nttdocomo.co.jp | Rel-8 |  | Michael |  |
| 151 | 47 | Study on Non 3GPP access NSP | 207d? | 2006-12-06 A | 2007-09-20 | 40% | 124.2d? | 2006-12-06 | 2007-09-20 | 207d? | 397d | start no earlier than 2006-12-06 | S1 | 1656h | 662.4h | N3GtoNSP | 22.812 | Chris Friel (O2) | chris.friel@o2.com | Rel-8 |  | Michael |  |
| 152 | 48 | Study on Value Added Services for Short Message Service | 263d? | 2006-12-06 A | 2007-12-07 | 60% | 105.2d? | 2006-12-06 | 2007-12-07 | 263d? | 341d | finish no earlier than 2007-12-07 | S1 | 2104h | 1262.4h | VAS4SMS | 22.xxx | Wu Bin (China Mobile Communications Corporation) | wubin@chinamobile.com | Rel-8 |  | Michael |  |
| 153 | 49 | Study on Requirements for seamless roaming and service continuity between mobile and WLAN networks | 262d? | 2006-12-06 A | 2007-12-06 | 20% | 209.6d? | 2006-12-06 | 2007-06-07 | 132d? | 342d | finish no earlier than 2007-12-06 | S1 | 2096h | 419.2h | SMLSWLAN | 22.937 | Mike Meyerstein (BT) | mike.meyerstein@bt.com | Rel-8 |  | Michael |  |
| 154 | 50 | Feasibility Study of Mobility between 3GPP-WLAN Interworking and 3GPP Systems | 129d? | 2007-03-20 A | 2007-09-14 | 40% | 77.4d? |  |  |  | 401d | start no earlier than 2007-03-20 | S2 | 1032h | 412.8h | SM3GWLAN | 23.837 | Orange | orange | Rel-8 |  | Maurice |  |
| 155 | 51 | **OAM&P Rel-8 Studies (not yet official)** | 725d? | 2005-09-02 A | 2008-06-12 | 43% | 411.78d? |  |  |  | 207d |  | S5 | 19225.6h | 6884.8h |  |  |  |  | Rel-8 |  | Adrian |  |
| 156 | 51.1 | Study of Element Operations Systems Function (EOSF) definition | 596d? | 2005-09-02 A | 2007-12-14 | 20% | 476.8d? | 2005-09-02 | 2008-12-15 | 857d? | 336d | finish no earlier than 2007-12-14 | S5 | 4768h | 953.6h |  | TR 32.819 | China Mobile |  | Rel-8 |  |  | SP-32 |
| 157 | 51.2 | Study on SA5 MTOSI XML Harmonization | 418d? | 2006-05-10 A | 2007-12-14 | 90% | 41.8d? | 2006-05-10 | 2008-12-15 | 679d? | 336d | finish no earlier than 2007-12-14 | S5 | 3344h | 3009.6h |  | TR 32.818 | Nortel |  | Rel-8 |  |  | SP-32 |
| 158 | 51.3 | Study of Common Profile Storage (CPS) Framework of User Data for network services and management | 244d? | 2006-07-03 A | 2007-06-07 A | 100% |  | 2006-07-03 | 2007-03-15 | 184d? |  | finish no earlier than 2007-06-07 | S5 | 1952h | 1952h |  | TR 32.808 | T-Mobile |  | Rel-8 |  |  |  |
| 159 | 51.4 | Study of Management for LTE and SAE | 202d? | 2006-12-07 A | 2007-09-14 | 60% | 80.8d? | 2006-12-07 | 2007-06-14 | 136d? | 401d | finish no earlier than 2007-09-14 | S5 | 1616h | 969.6h |  | TR 32.816 | Ericsson |  | Rel-8 |  |  |  |
| 160 | 51.5 | Study of System Maintenance by Itf-N | 266d? | 2007-06-07 | 2008-06-12 |  |  |  |  |  | 207d | finish no earlier than 2008-06-12 | S5 | 2128h |  |  | TR 32.8xy | ZTE |  | Rel-8 |  |  |  |
| 161 | 51.6 | Study of Self-Organizing Networks (SON) related OAM interfaces for Home NodeB | 266d? | 2007-06-07 | 2008-06-12 |  |  |  |  |  | 207d | finish no earlier than 2008-06-12 | S5 | 2128h |  |  | TR 32.8xy | Huawei |  | Rel-8 |  |  |  |
| 162 | 52 | SI on AS-MRFC media server control protocol | 318d? | 2006-03-22 A | 2007-06-08 | 75% | 79.5d? | 2006-03-22 | 2007-06-08 | 318d? | 471d | finish no earlier than 2007-06-08 | C1 | 2544h | 1908h | MRFC | New TR 24.880 | Mark Syrett (Hewlett-Packard) |  | Rel-8 |  |  |  |
| 163 | 53 | FS Restoration Procedures | 180d? | 2007-03-26 A | 2007-11-30 | 10% | 162d? |  |  |  | 346d | start no earlier than 2007-03-26 | C4 | 1440h | 144h | FSIMS8_RP | New TR 23.xyz | German Blanco (Ericsson) | german.blanco@ericsson.com | Rel-8 |  | Kimmo |  |
| 164 | 54 | FS on 3G Home NodeB/eNodeB | 210d? | 2007-03-05 A | 2007-12-21 | 10% | 189d? |  |  |  | 331d | finish no earlier than 2007-12-21 | R4 | 1680h | 168h | RANFS-HNBeNB |  | Howard Thomas (Motorola) |  | Rel-8 |  | Claude |  |
| 165 | 55 | FS on MMSC | 158d? | 2007-04-26 A | 2007-12-03 | 5% | 150.1d? |  |  |  | 345d | finish no earlier than 2007-12-01 | S2 | 1264h | 63.2h | MMSC_FS | 23.8yz |  |  | Rel-8 |  | Maurice |  |
| 166 | 56 | FS on CS Domain Services over evolved PS access | 328d? | 2007-04-25 | 2008-07-25 |  |  |  |  |  | 176d | finish no earlier than 2008-07-25 | S2 | 2624h |  | FS_CSoPS | 23.8nn | Sabine Demel (T-Mobile International) | Sabine (dot) Demel (at) T-Mobile (dot) at | Rel-8 |  | Maurice |  |
| 167 | 57 | FS on Transferring of emergency call data – in-band modem solution | 131d? | 2006-12-07 A | 2007-06-07 | 50% | 65.5d? | 2006-12-07 | 2007-06-07 | 131d? | 472d | finish no earlier than 2007-06-07 | S4 | 1048h | 524h | eCALLIBMS | 26.967 | Leon Hong, Airbiquity | lhong@airbiquity.com | Rel-8 |  | Paolo |  |
| 168 | 58 | FS on Improved network controlled mobility between LTE and 3GPP2/mobile WiMAX radio technologies | 131d? | 2007-06-04 | 2007-12-03 |  |  |  |  |  | 345d | finish no earlier than 2007-12-03 | R2 | 1048h |  | RANFS-LTEmob | 25.9xx |  |  | Rel-8 |  |  |  |

Notes:
- 143: Study approved SA#32
- 146: Formerly called "Consumer protection against spam and malware"
- 148: Approved at SP#33
- 153: Revised at SA#36
- 154: Rapporteur name to be provided. Supporting companies: T-Mobile, Orange, China Mobile, Telenor, Alcatel-Lucent, Azaire Networks, Airvana
- 155: Created to encompass the Rel7 Work Tasks shifted to Rel8
- 156: Request to TSG#35 to move to Release 8
- 157: Request to TSG#35 to move to Release 8
- 158: Submit Exception Sheet for TSG#35 Approval
- 159: 12/2006 SA#34 WID approved
- 165: SID created at S2-57
- 166: SID created at S2-57
- 167: Moved from Rel7
